# BB-02 - gietbouw met tunnelkist

Schedule from MS Project, 2003-01-12 to 2003-01-26, status date 2003-01-08.
BAM Nelissen Van Egteren

## Calendars

- ALLEEN WERKDAGEN: Mon-Fri 08:30-12:30, 13:00-17:00; Sat-Sun off. Exceptions (off unless hours are given): 2003-01-11 to 2003-01-12 08:30-12:30, 13:00-17:00, 2003-01-18 to 2003-01-19 08:30-12:30, 13:00-17:00, 2003-01-25 to 2003-01-26 08:30-12:30, 13:00-17:00.

## Schedule

| ID | WBS | Task | Type | Duration | Start | Finish | Predecessors | Total slack | Constraint |
| --- | --- | --- | --- | --- | --- | --- | --- | --- | --- |
| 1 | 1 | BB-02 GIETBOUW MET TUNNELKIST | milestone | 0d | 2003-01-12 | 2003-01-12 |  | 0d | start no earlier than 2003-01-12 |
| 2 | 2 | **BOVENBOUWFASE** |  | 15d | 2003-01-12 | 2003-01-26 |  | 0d |  |
| 3 | 2.1 | kimmen op beg.grond aanbrengen |  | 1d | 2003-01-12 | 2003-01-12 | 1 | 0d |  |
| 4 | 2.2 | tunnelkist op beg.grond stellen |  | 4d | 2003-01-13 | 2003-01-16 | 3SS+1d | 0d |  |
| 5 | 2.3 | 1e verd.vloer tunnelkist storten |  | 4d | 2003-01-14 | 2003-01-17 | 4SS+1d | 0d |  |
| 6 | 2.4 | tunnelkist op 1e verd.vloer stellen |  | 4d | 2003-01-18 | 2003-01-21 | 5SS+4d | 0d |  |
| 7 | 2.5 | 2e verd.vloer tunnelkist storten |  | 4d | 2003-01-19 | 2003-01-22 | 6SS+1d | 0d |  |
| 8 | 2.6 | zoldervloer topkisten stellen |  | 4d | 2003-01-23 | 2003-01-26 | 7SS+4d | 0d |  |
| 9 | 2.7 | start gevels+ daken | milestone | 0d | 2003-01-26 | 2003-01-26 | 8SS+4d | 0d |  |
